| id | name | startDate | endDate | priority | barScale | progress | type | parentId | dependencies |
| --- | --- | --- | --- | --- | --- | --- | --- | --- | --- |
| 1 | Landscaping Project | 2026-06-01T00:00:00.000Z | 2026-08-24T00:00:00.000Z | medium | 1 | 0 | group |  |  |
| 2 | Site walk and design | 2026-06-01T00:00:00.000Z | 2026-06-08T00:00:00.000Z | medium | 1 | 0 | task | 1 |  |
| 3 | Final design and selects | 2026-06-08T00:00:00.000Z | 2026-06-15T00:00:00.000Z | medium | 1 | 0 | task | 1 | 2 FS |
| 4 | Permits and HOA | 2026-06-08T00:00:00.000Z | 2026-06-22T00:00:00.000Z | medium | 1 | 0 | task | 1 |  |
| 5 | Remove existing | 2026-06-15T00:00:00.000Z | 2026-06-19T00:00:00.000Z | medium | 1 | 0 | task | 1 |  |
| 6 | Grade for drainage | 2026-06-19T00:00:00.000Z | 2026-06-23T00:00:00.000Z | high | 1 | 0 | task | 1 | 5 FS |
| 7 | French drains | 2026-06-23T00:00:00.000Z | 2026-06-26T00:00:00.000Z | medium | 1 | 0 | task | 1 |  |
| 8 | Irrigation main line | 2026-06-26T00:00:00.000Z | 2026-06-29T00:00:00.000Z | medium | 1 | 0 | task | 1 |  |
| 9 | Hardscape base prep | 2026-06-29T00:00:00.000Z | 2026-07-04T00:00:00.000Z | medium | 1 | 0 | task | 1 |  |
| 10 | Patio and walkways | 2026-07-04T00:00:00.000Z | 2026-07-14T00:00:00.000Z | medium | 1 | 0 | task | 1 | 9 FS |
| 11 | Retaining walls | 2026-07-06T00:00:00.000Z | 2026-07-13T00:00:00.000Z | medium | 1 | 0 | task | 1 |  |
| 12 | Fire pit or kitchen | 2026-07-13T00:00:00.000Z | 2026-07-18T00:00:00.000Z | medium | 1 | 0 | task | 1 |  |
| 13 | Irrigation drip lines | 2026-07-20T00:00:00.000Z | 2026-07-25T00:00:00.000Z | medium | 1 | 0 | task | 1 |  |
| 14 | Test irrigation zones | 2026-07-25T00:00:00.000Z | 2026-07-26T00:00:00.000Z | medium | 1 | 0 | milestone | 1 |  |
| 15 | Soil amendment | 2026-07-26T00:00:00.000Z | 2026-07-29T00:00:00.000Z | medium | 1 | 0 | task | 1 |  |
| 16 | Plant trees | 2026-07-29T00:00:00.000Z | 2026-08-01T00:00:00.000Z | medium | 1 | 0 | task | 1 |  |
| 17 | Plant shrubs | 2026-08-01T00:00:00.000Z | 2026-08-05T00:00:00.000Z | medium | 1 | 0 | task | 1 |  |
| 18 | Plant perennials | 2026-08-05T00:00:00.000Z | 2026-08-09T00:00:00.000Z | medium | 1 | 0 | task | 1 |  |
| 19 | Mulch | 2026-08-09T00:00:00.000Z | 2026-08-11T00:00:00.000Z | medium | 1 | 0 | task | 1 |  |
| 20 | Lay sod | 2026-08-13T00:00:00.000Z | 2026-08-16T00:00:00.000Z | medium | 1 | 0 | task | 1 |  |
| 21 | Low-voltage lighting | 2026-08-16T00:00:00.000Z | 2026-08-19T00:00:00.000Z | medium | 1 | 0 | task | 1 |  |
| 22 | Irrigation programming | 2026-08-20T00:00:00.000Z | 2026-08-22T00:00:00.000Z | medium | 1 | 0 | task | 1 |  |
| 23 | Final walkthrough | 2026-08-22T00:00:00.000Z | 2026-08-23T00:00:00.000Z | medium | 1 | 0 | milestone | 1 |  |
